# Cronograma_PMA

Schedule from MS Project, 2010-01-01 to 2012-06-18, status date 2010-08-29.
Hewlett-Packard

## Calendars

- Obra Civil: Mon-Sun 09:00-13:00, 15:00-19:00. Exceptions (off unless hours are given): 2010-01-01 to 2012-02-01 09:00-13:00, 15:00-19:00.

## Schedule

| ID | WBS | Task | Duration | Start | Finish | Predecessors | Total slack | Constraint |
| --- | --- | --- | --- | --- | --- | --- | --- | --- |
| 1 | 1 | **PLAN DE MANEJO AMBIENTAL** | 900d | 2010-01-01 | 2012-06-18 |  | 0d |  |
| 2 | 1.1 | **Programa de Medidas Preventivas/Mitigadoras y Correctivas** | 900d | 2010-01-01 | 2012-06-18 |  | 0d |  |
| 3 | 1.1.1 | Sub programa de Manejo de Residuos Solidos, Liquidos y Efluentes | 900d | 2010-01-01 | 2012-06-18 |  | 0d |  |
| 4 | 1.1.2 | **Sub Programa de Señalización Ambiental** | 900d | 2010-01-01 | 2012-06-18 |  | 0d |  |
| 5 | 1.1.2.1 | Señalización Temporal | 420d | 2010-01-01 | 2011-02-24 |  | 0d |  |
| 6 | 1.1.2.2 | Señalización Definitiva | 480d | 2011-02-25 | 2012-06-18 | 5 | 0d |  |
| 7 | 1.2 | **Programa de Capacitacion, Educacion Ambiental y Seguridad** | 900d | 2010-01-01 | 2012-06-18 | 2SS | 0d |  |
| 8 | 1.2.1 | Sub Programa de Educación Ambiental y Seguridad Vial | 900d | 2010-01-01 | 2012-06-18 | 2SS | 0d |  |
| 9 | 1.2.2 | Sub Programa de Capacitación Ambiental y Seguridad Vial | 900d | 2010-01-01 | 2012-06-18 | 2SS | 0d |  |
| 10 | 1.3 | **Programa de Monitoreo Ambiental** | 840d | 2010-03-02 | 2012-06-18 | 2SS | 0d |  |
| 11 | 1.3.1 | **Monitoreo Ambiental de Aire** | 840d | 2010-03-02 | 2012-06-18 |  | 0d |  |
| 12 | 1.3.1.1 | Monitoreo Ambiental de Aire N° 01 (Trimestral) | 30d | 2010-03-02 | 2010-03-31 |  | 0d | start no earlier than 2010-03-02 |
| 13 | 1.3.1.2 | Monitoreo Ambiental de Aire N° 02 (Trimestral) | 30d | 2010-05-31 | 2010-06-29 | 12FS+60d | 0d |  |
| 14 | 1.3.1.3 | Monitoreo Ambiental de Aire N° 03 (Trimestral) | 30d | 2010-08-29 | 2010-09-27 | 13FS+60d | 0d |  |
| 15 | 1.3.1.4 | Monitoreo Ambiental de Aire N° 04 (Trimestral) | 30d | 2010-11-27 | 2010-12-26 | 14FS+60d | 0d |  |
| 16 | 1.3.1.5 | Monitoreo Ambiental de Aire N° 05 (Trimestral) | 30d | 2011-02-25 | 2011-03-26 | 15FS+60d | 0d |  |
| 17 | 1.3.1.6 | Monitoreo Ambiental de Aire N° 06 (Trimestral) | 30d | 2011-05-26 | 2011-06-24 | 16FS+60d | 0d |  |
| 18 | 1.3.1.7 | Monitoreo Ambiental de Aire N° 07 (Trimestral) | 30d | 2011-08-24 | 2011-09-22 | 17FS+60d | 0d |  |
| 19 | 1.3.1.8 | Monitoreo Ambiental de Aire N° 08 (Trimestral) | 30d | 2011-11-22 | 2011-12-21 | 18FS+60d | 0d |  |
| 20 | 1.3.1.9 | Monitoreo Ambiental de Aire N° 09 (Trimestral) | 30d | 2012-02-20 | 2012-03-20 | 19FS+60d | 0d |  |
| 21 | 1.3.1.10 | Monitoreo Ambiental de Aire N° 10 (Trimestral) | 30d | 2012-05-20 | 2012-06-18 | 20FS+60d | 0d |  |
| 22 | 1.3.2 | **Monitoreo Ambiental de Ruido** | 840d | 2010-03-02 | 2012-06-18 |  | 0d |  |
| 23 | 1.3.2.1 | Monitoreo Ambiental de Ruido N° 01 (Trimestral) | 30d | 2010-03-02 | 2010-03-31 |  | 0d | start no earlier than 2010-03-02 |
| 24 | 1.3.2.2 | Monitoreo Ambiental de Ruido N° 02 (Trimestral) | 30d | 2010-05-31 | 2010-06-29 | 23FS+60d | 0d |  |
| 25 | 1.3.2.3 | Monitoreo Ambiental de Ruido N° 03 (Trimestral) | 30d | 2010-08-29 | 2010-09-27 | 24FS+60d | 0d |  |
| 26 | 1.3.2.4 | Monitoreo Ambiental de Ruido N° 04 (Trimestral) | 30d | 2010-11-27 | 2010-12-26 | 25FS+60d | 0d |  |
| 27 | 1.3.2.5 | Monitoreo Ambiental de Ruido N° 05 (Trimestral) | 30d | 2011-02-25 | 2011-03-26 | 26FS+60d | 0d |  |
| 28 | 1.3.2.6 | Monitoreo Ambiental de Ruido N° 06 (Trimestral) | 30d | 2011-05-26 | 2011-06-24 | 27FS+60d | 0d |  |
| 29 | 1.3.2.7 | Monitoreo Ambiental de Ruido N° 07 (Trimestral) | 30d | 2011-08-24 | 2011-09-22 | 28FS+60d | 0d |  |
| 30 | 1.3.2.8 | Monitoreo Ambiental de Ruido N° 08 (Trimestral) | 30d | 2011-11-22 | 2011-12-21 | 29FS+60d | 0d |  |
| 31 | 1.3.2.9 | Monitoreo Ambiental de Ruido N° 09 (Trimestral) | 30d | 2012-02-20 | 2012-03-20 | 30FS+60d | 0d |  |
| 32 | 1.3.2.10 | Monitoreo Ambiental de Ruido N° 10 (Trimestral) | 30d | 2012-05-20 | 2012-06-18 | 31FS+60d | 0d |  |

| ID | WBS | Task | Duration | Start | Finish | Predecessors | Total slack | Constraint |
| --- | --- | --- | --- | --- | --- | --- | --- | --- |
| 33 | 1.3.3 | **Monitoreo Ambiental de Agua** | 840d | 2010-03-02 | 2012-06-18 |  | 0d |  |
| 34 | 1.3.3.1 | Monitoreo Ambiental de Agua N° 01 (Trimestral) | 30d | 2010-03-02 | 2010-03-31 |  | 0d | start no earlier than 2010-03-02 |
| 35 | 1.3.3.2 | Monitoreo Ambiental de Agua N° 02 (Trimestral) | 30d | 2010-05-31 | 2010-06-29 | 34FS+60d | 0d |  |
| 36 | 1.3.3.3 | Monitoreo Ambiental de Agua N° 03 (Trimestral) | 30d | 2010-08-29 | 2010-09-27 | 35FS+60d | 0d |  |
| 37 | 1.3.3.4 | Monitoreo Ambiental de Agua N° 04 (Trimestral) | 30d | 2010-11-27 | 2010-12-26 | 36FS+60d | 0d |  |
| 38 | 1.3.3.5 | Monitoreo Ambiental de Agua N° 05 (Trimestral) | 30d | 2011-02-25 | 2011-03-26 | 37FS+60d | 0d |  |
| 39 | 1.3.3.6 | Monitoreo Ambiental de Agua N° 06 (Trimestral) | 30d | 2011-05-26 | 2011-06-24 | 38FS+60d | 0d |  |
| 40 | 1.3.3.7 | Monitoreo Ambiental de Agua N° 07 (Trimestral) | 30d | 2011-08-24 | 2011-09-22 | 39FS+60d | 0d |  |
| 41 | 1.3.3.8 | Monitoreo Ambiental de Agua N° 08 (Trimestral) | 30d | 2011-11-22 | 2011-12-21 | 40FS+60d | 0d |  |
| 42 | 1.3.3.9 | Monitoreo Ambiental de Agua N° 09 (Trimestral) | 30d | 2012-02-20 | 2012-03-20 | 41FS+60d | 0d |  |
| 43 | 1.3.3.10 | Monitoreo Ambiental de Agua N° 10 (Trimestral) | 30d | 2012-05-20 | 2012-06-18 | 42FS+60d | 0d |  |
| 44 | 1.4 | **Programa de Asuntos Sociales** | 900d | 2010-01-01 | 2012-06-18 |  | 0d |  |
| 45 | 1.4.1 | **Sub Programa de Relaciones Comunitarias** | 900d | 2010-01-01 | 2012-06-18 | 2SS | 0d |  |
| 46 | 1.4.1.1 | Diseño e Implementacion de Medios Comunicación | 900d | 2010-01-01 | 2012-06-18 |  | 0d |  |
| 47 | 1.4.1.2 | Elaboracion y Difusion del Codigo de Conducta | 900d | 2010-01-01 | 2012-06-18 |  | 0d |  |
| 48 | 1.4.2 | **Contratación de Mano de Obra Local** | 900d | 2010-01-01 | 2012-06-18 |  | 0d |  |
| 49 | 1.4.2.1 | Diseño y Coordinación con Autoridades y Gremios | 900d | 2010-01-01 | 2012-06-18 |  | 0d |  |
| 50 | 1.4.2.2 | Convocatoria y Selección | 900d | 2010-01-01 | 2012-06-18 |  | 0d |  |
| 51 | 1.4.2.3 | Diseño e Implementación de Sistema Comunicación | 120d | 2010-01-01 | 2010-04-30 |  | 780d |  |
| 52 | 1.5 | **Programa de Prevencion de Perdidas y Contingencis** | 900d | 2010-01-01 | 2012-06-18 |  | 0d |  |
| 53 | 1.5.1 | **Sub Programa de Salud Ocupacional** | 900d | 2010-01-01 | 2012-06-18 |  | 0d |  |
| 54 | 1.5.1.1 | Examen Medico N°01 (Inicio de Obra) | 30d | 2010-01-01 | 2010-01-30 |  | 0d |  |
| 55 | 1.5.1.2 | Examen Medico N°02 (10 meses de inicida la obra) | 30d | 2010-09-28 | 2010-10-27 | 54FS+240d | 0d |  |
| 56 | 1.5.1.3 | Examen Medico N°03 (20 meses de inicida la obra) | 30d | 2011-07-25 | 2011-08-23 | 55FS+270d | 0d |  |
| 57 | 1.5.1.4 | Examen Medico N°04 (Fin de Obra) | 30d | 2012-05-20 | 2012-06-18 | 56FS+270d | 0d |  |
| 58 | 1.5.2 | Sub Programa de Prevencion de Contingencias y Respuestas a Emergencias | 900d | 2010-01-01 | 2012-06-18 | 2SS | 0d |  |

| ID | WBS | Task | Duration | Start | Finish | Predecessors | Total slack | Constraint |
| --- | --- | --- | --- | --- | --- | --- | --- | --- |
| 59 | 1.6 | **Programa de Abandono de Obra** | 120d | 2012-02-20 | 2012-06-18 | 2SS+360d | 0d |  |
| 60 | 1.6.1 | Readecuacion Ambiental de Canteras | 120d | 2012-02-20 | 2012-06-18 |  | 0d | finish no earlier than 2012-06-18 |
| 61 | 1.6.2 | Disposicion y Conformacion de Material Excedente | 60d | 2012-04-20 | 2012-06-18 | 60FF | 0d |  |
| 62 | 1.6.3 | Readecuacion Ambiental de plantas de trituracion de Azfalto | 120d | 2012-02-20 | 2012-06-18 | 61FF | 0d |  |
| 63 | 1.6.4 | Readecuacion Ambiental de Campamentos y Patio de Maquinas | 30d | 2012-05-20 | 2012-06-18 | 62FF | 0d |  |
